# Cas TNP

Schedule from MS Project, 2014-05-19 to 2014-09-26, costs in €.

## Calendars

- Standard: Mon-Fri 08:00-12:00, 13:00-17:00; Sat-Sun off.

## Resources

| Resource | Group | Rate | Cost per use |
| --- | --- | --- | --- |
| ING | TERTEL | 150 |  |
| TEC | TERTEL | 80 |  |
| Sous-traitant N°1 | PRINT SYSTEM |  | 1500 |

## Schedule

| ID | WBS | Task | Type | Duration | Start | Finish | Predecessors | Total slack | Free slack | Resources | Work | Cost |
| --- | --- | --- | --- | --- | --- | --- | --- | --- | --- | --- | --- | --- |
| 1 | Jalon 1 | Début du projet | milestone | 0d | 2014-05-19 | 2014-05-19 |  | 0d |  |  |  |  |
| 2 | 1.4 | **Logiciel LOGIC** |  | 95d | 2014-05-19 | 2014-09-26 |  | 0d |  |  | 2180h | 259,900 |
| 3 | 1.4.A | Réaliser les spécifications et la conception générale du logiciel |  | 30d | 2014-05-19 | 2014-06-27 | 1 | 0d |  | ING [200%]; TEC | 720h | 91,200 |
| 4 | 1.4.B | Tester le fonctionnement de l'ensemble des modules |  | 20d | 2014-09-01 | 2014-09-26 | 11, 15 | 0d |  | ING [50%]; TEC | 240h | 24,800 |
| 5 | 1.4.1 | **Module N°1** |  | 15d | 2014-06-30 | 2014-07-18 |  | 0d |  |  | 120h | 18,000 |
| 6 | 1.4.1.A | Coder, tester et intégrer le Module 1 |  | 15d | 2014-06-30 | 2014-07-18 | 3 | 0d |  | ING | 120h | 18,000 |
| 7 | Jalon 2 | Fin du Module N°1 | milestone | 0d | 2014-07-18 | 2014-07-18 | 6 | 0d |  |  |  |  |
| 8 | 1.4.2 | **Module N°2** |  | 10d | 2014-06-30 | 2014-07-11 |  | 20d |  |  | 40h | 6,000 |
| 9 | 1.4.2.A | Coder, tester et intégrer le Module 2 |  | 10d | 2014-06-30 | 2014-07-11 | 3 | 20d | 0d | ING [50%] | 40h | 6,000 |
| 10 | 1.4.3 | **Module N°3** |  | 15d | 2014-07-14 | 2014-08-01 |  | 20d |  |  | 300h | 32,400 |
| 11 | 1.4.3.A | Coder, tester et intégrer le Module 3 |  | 15d | 2014-07-14 | 2014-08-01 | 9 | 20d |  | ING; TEC [150%] | 300h | 32,400 |
| 12 | 1.4.4 | **Module N°4** |  | 10d | 2014-07-21 | 2014-08-01 |  | 0d |  |  | 160h | 18,400 |
| 13 | 1.4.4.A | Coder, tester et intégrer le Module 4 |  | 10d | 2014-07-21 | 2014-08-01 | 7 | 0d |  | ING; TEC | 160h | 18,400 |
| 14 | 1.4.5 | **Module N°5** |  | 20d | 2014-08-04 | 2014-08-29 |  | 0d |  |  | 320h | 25,600 |
| 15 | 1.4.5.A | Coder, tester et intégrer le Module 5 |  | 20d | 2014-08-04 | 2014-08-29 | 13 | 0d |  | TEC [200%] | 320h | 25,600 |
| 16 | 1.4.6 | **Doc technique et mode d'emploi** |  | 35d | 2014-07-18 | 2014-09-05 |  | 15d |  |  | 280h | 43,500 |
| 17 | 1.4.6.A | Rédiger la documentation technique et le mode d'emploi et les faire imprimer |  | 35d | 2014-07-18 | 2014-09-05 | 7 | 15d |  | ING; Sous-traitant N°1 | 280h | 43,500 |
| 18 | Jalon 3 | Fin du projet | milestone | 0d | 2014-09-26 | 2014-09-26 | 4, 17 | 0d |  |  |  |  |
